# 1

Schedule from MS Project, 2011-11-09 to 2013-11-10.

## Calendars

- Calendar 1: Mon-Thu 08:00-12:00, 13:00-17:00; Fri off; Sat-Sun 08:00-12:00, 13:00-17:00.

## Schedule

| ID | WBS | Task | Duration | Start | Finish | Predecessors | Total slack |
| --- | --- | --- | --- | --- | --- | --- | --- |
| 1 | 1 | **تجهیز و برچیدن کارگاه** | 628d | 2011-11-09 | 2013-11-10 |  | 0d |
| 2 | 1.1 | **خاكبرداري و پي سازي** | 142d | 2011-11-09 | 2012-04-22 |  | 0d |
| 3 | 1.1.1 | **خاك برداري** | 85d | 2011-11-09 | 2012-02-15 |  | 0d |
| 4 | 1.1.1.1 | نقشه برداري | 5d | 2011-11-09 | 2011-11-14 |  | 0d |
| 5 | 1.1.1.2 | خاك برداري | 80d | 2011-11-15 | 2012-02-15 | 4 | 0d |
| 6 | 1.1.2 | **پي سازي** | 57d | 2012-02-16 | 2012-04-22 | 3 | 0d |
| 7 | 1.1.2.1 | بتن مگر | 9d | 2012-02-16 | 2012-02-26 | 5 | 0d |
| 8 | 1.1.2.2 | آرماتور بندي | 35d | 2012-02-27 | 2012-04-07 | 7 | 0d |
| 9 | 1.1.2.3 | قالب بندي | 8d | 2012-04-08 | 2012-04-16 | 8 | 0d |
| 10 | 1.1.2.4 | بتن ريزي | 5d | 2012-04-17 | 2012-04-22 | 9 | 0d |
| 11 | 1.2 | **اجراي اسكلت فلزي** | 232d | 2012-04-23 | 2013-01-17 | 6 | 0d |
| 12 | 1.2.1 | **ساخت اسكلت** | 74d | 2012-04-23 | 2012-07-17 |  | 0d |
| 13 | 1.2.1.1 | برش كاري | 22d | 2012-04-23 | 2012-05-17 |  | 0d |
| 14 | 1.2.1.2 | ساخت ستون ها | 30d | 2012-05-19 | 2012-06-21 | 13 | 0d |
| 15 | 1.2.1.3 | ساخت تير ورق ها | 22d | 2012-06-23 | 2012-07-17 | 14 | 0d |
| 16 | 1.2.2 | **نصب اسكلت** | 75d | 2012-07-18 | 2012-10-13 |  | 0d |
| 17 | 1.2.2.1 | نصب ستون ها | 23d | 2012-07-18 | 2012-08-13 | 15 | 0d |
| 18 | 1.2.2.2 | نصب تير ها | 52d | 2012-08-14 | 2012-10-13 | 17 | 0d |
| 19 | 1.2.3 | **اجراي سقف كامپوزيت** | 83d | 2012-10-14 | 2013-01-17 |  | 0d |
| 20 | 1.2.3.1 | قالب بندي | 55d | 2012-10-14 | 2012-12-16 | 18 | 0d |
| 21 | 1.2.3.2 | آرماتور بندي | 11d | 2012-12-17 | 2012-12-29 | 20 | 0d |
| 22 | 1.2.3.3 | بتن ريزي | 17d | 2012-12-30 | 2013-01-17 | 21 | 0d |
| 23 | 1.3 | **اجراي سفت كاري** | 72d | 2013-01-19 | 2013-04-11 |  | 0d |
| 24 | 1.3.1 | اجراي ديوار چني | 55d | 2013-01-19 | 2013-03-23 | 22 | 0d |
| 25 | 1.3.2 | نصب چهار چوب و فريم پنجره | 17d | 2013-03-24 | 2013-04-11 | 24 | 0d |

Notes:
- 16: قبل از نصب اسكلت و اجراي سفت كاري حفاظ مناسب در قسمت پياده رو در شرق ساختمان ايجاد گردد.

| ID | WBS | Task | Duration | Start | Finish | Predecessors | Total slack | Free slack |
| --- | --- | --- | --- | --- | --- | --- | --- | --- |
| 26 | 1.4 | **اجراي نازك كاري** | 486d | 2012-04-23 | 2013-11-10 |  | 0d |  |
| 27 | 1.4.1 | اجراي گچ و خاك | 59d | 2013-04-13 | 2013-06-19 | 25 | 0d |  |
| 28 | 1.4.2 | كرم و شيب بندي | 59d | 2012-04-23 | 2012-06-30 | 10 | 328d | 0d |
| 29 | 1.4.3 | اجراي ايرولاسيون | 18d | 2012-07-01 | 2012-07-21 | 28 | 328d | 0d |
| 30 | 1.4.4 | اجراي سراميك و كاشي كاري | 35d | 2012-07-22 | 2012-08-30 | 29 | 328d |  |
| 31 | 1.4.5 | اجراي سفيد كاري | 48d | 2013-06-20 | 2013-08-14 | 27 | 0d |  |
| 32 | 1.4.6 | اجرای سنگ نما | 43d | 2013-04-13 | 2013-06-01 | 24, 25 | 149d |  |
| 33 | 1.4.7 | نصب شیشه | 11d | 2013-08-15 | 2013-08-27 | 31 | 0d |  |
| 34 | 1.4.8 | اجراي رنگ آميزي | 56d | 2013-08-28 | 2013-10-31 | 30, 33 | 0d |  |
| 35 | 1.4.9 | تمیزکاری و تحویل | 8d | 2013-11-02 | 2013-11-10 | 34, 32 | 0d |  |
