# 1222222222222222222222

Schedule from MS Project, 2011-11-09 to 2013-03-06.

## Calendars

- Calendar 1: Mon-Thu 08:00-12:00, 13:00-17:00; Fri off; Sat-Sun 08:00-12:00, 13:00-17:00.

## Schedule

| ID | WBS | Task | Duration | Start | Finish | Predecessors | Total slack | Free slack |
| --- | --- | --- | --- | --- | --- | --- | --- | --- |
| 1 | 1 | **تجهیز و برچیدن کارگاه** | 415d | 2011-11-09 | 2013-03-06 |  | 0d |  |
| 2 | 1.1 | **خاكبرداري و پي سازي** | 53d | 2011-11-09 | 2012-01-09 |  | 0d |  |
| 3 | 1.1.1 | **خاك برداري** | 25d | 2011-11-09 | 2011-12-07 |  | 0d |  |
| 4 | 1.1.1.1 | نقشه برداري | 3d | 2011-11-09 | 2011-11-12 |  | 0d |  |
| 5 | 1.1.1.2 | خاك برداري | 22d | 2011-11-13 | 2011-12-07 | 4 | 0d |  |
| 6 | 1.1.2 | **پي سازي** | 28d | 2011-12-08 | 2012-01-09 | 3 | 0d |  |
| 7 | 1.1.2.1 | بتن مگر | 6d | 2011-12-08 | 2011-12-14 | 5 | 0d |  |
| 8 | 1.1.2.2 | آرماتور بندي | 13d | 2011-12-15 | 2011-12-29 | 7 | 0d |  |
| 9 | 1.1.2.3 | قالب بندي | 7d | 2011-12-31 | 2012-01-07 | 8 | 0d |  |
| 10 | 1.1.2.4 | بتن ريزي | 2d | 2012-01-08 | 2012-01-09 | 9 | 0d |  |
| 11 | 1.2 | **اجراي اسكلت بتنی و سقف** | 133d | 2012-01-10 | 2012-06-12 | 6 | 0d |  |
| 12 | 1.2.1 | اجراي اسكلت و سقف اول | 19d | 2012-01-10 | 2012-01-31 |  | 0d |  |
| 13 | 1.2.2 | اجراي اسكلت و سقف دوم | 19d | 2012-02-01 | 2012-02-22 | 12 | 0d |  |
| 14 | 1.2.3 | اجراي اسكلت و سقف سوم | 19d | 2012-02-23 | 2012-03-15 | 13 | 0d |  |
| 15 | 1.2.4 | اجراي اسكلت و سقف چهارم | 19d | 2012-03-17 | 2012-04-07 | 14 | 0d |  |
| 16 | 1.2.5 | اجراي اسكلت و سقف پنجم | 19d | 2012-04-08 | 2012-04-29 | 15 | 0d |  |
| 17 | 1.2.6 | اجراي اسكلت و سقف ششم | 19d | 2012-04-30 | 2012-05-21 | 16 | 0d |  |
| 18 | 1.2.7 | اجراي اسكلت و سقف هفتم | 19d | 2012-05-22 | 2012-06-12 | 17 | 0d |  |
| 19 | 1.3 | **اجراي سفت كاري** | 57d | 2012-06-13 | 2012-08-18 | 11 | 0d |  |
| 20 | 1.3.1 | اجراي ديوار چني | 48d | 2012-06-13 | 2012-08-07 |  | 0d |  |
| 21 | 1.3.2 | نصب چهار چوب و فريم پنجره | 9d | 2012-08-08 | 2012-08-18 | 20 | 0d |  |
| 22 | 1.4 | **اجراي نازك كاري** | 172d | 2012-08-19 | 2013-03-06 | 19 | 0d |  |
| 23 | 1.4.1 | نصب پنجره | 14d | 2012-08-19 | 2012-09-03 | 21 | 0d |  |
| 24 | 1.4.2 | اجراي گچ و خاك | 59d | 2012-09-04 | 2012-11-11 | 23 | 0d |  |
| 25 | 1.4.3 | كرم و شيب بندي | 59d | 2012-08-19 | 2012-10-25 | 20 | 74d | 0d |
| 26 | 1.4.4 | اجراي ايرولاسيون | 9d | 2012-10-27 | 2012-11-05 | 25 | 74d | 0d |
| 27 | 1.4.5 | اجراي سراميك و كاشي كاري | 22d | 2012-11-06 | 2012-12-01 | 26 | 74d |  |
| 28 | 1.4.6 | اجراي سفيد كاري | 48d | 2012-11-12 | 2013-01-06 | 24 | 0d |  |
| 29 | 1.4.7 | اجرای سنگ نما | 43d | 2012-08-19 | 2012-10-07 | 20, 21 | 121d |  |
| 30 | 1.4.8 | نصب شیشه | 6d | 2012-08-19 | 2012-08-25 |  | 115d |  |
| 31 | 1.4.9 | اجراي رنگ آميزي | 43d | 2013-01-07 | 2013-02-25 | 30, 28 | 0d |  |
| 32 | 1.4.10 | تمیزکاری و تحویل | 8d | 2013-02-26 | 2013-03-06 | 31, 29, 27 | 0d |  |
